# Внедрение системы управления проектами

Schedule from MS Project, 2004-09-01 to 2005-01-06.

## Calendars

- Стандартный: Mon-Fri 09:00-13:00, 14:00-18:00; Sat-Sun off. Exceptions (off unless hours are given): 2004-11-08, 2004-12-31.

## Schedule

| ID | WBS | Task | Type | Duration | Start | Finish | Predecessors | Total slack | Constraint | Text1 |
| --- | --- | --- | --- | --- | --- | --- | --- | --- | --- | --- |
| 1 | 1 | **Внедрение корпоративных стандартов** |  | 82d? | 2004-09-13 | 2005-01-06 |  | 0d |  | 10 |
| 2 | 1.1 | **Основные корпоративные стандарты** |  | 82d | 2004-09-13 | 2005-01-06 |  | 0d |  | 10 |
| 3 | 1.1.1 | **"Положение об управлении проектами в системе менеджмента ООО "Усольехимпром""** |  | 13d | 2004-10-11 | 2004-10-27 |  | 0d |  | 5,10 |
| 4 | 1.1.1.1 | Доработка |  | 1w | 2004-10-11 | 2004-10-15 |  | 0d | start no earlier than 2004-10-11 | 5,10 |
| 5 | 1.1.1.2 | Согласование |  | 3d | 2004-10-18 | 2004-10-20 | 4 | 0d |  | 5,10 |
| 6 | 1.1.1.3 | Подготовка приказа об утверждении |  | 3d | 2004-10-21 | 2004-10-25 | 5 | 0d |  | 5,10 |
| 7 | 1.1.1.4 | Подписание Приказа |  | 2d | 2004-10-26 | 2004-10-27 | 6 | 0d |  | 5,10 |
| 8 | 1.1.1.5 | Подписаннный Приказ | milestone | 0d | 2004-10-27 | 2004-10-27 | 7 | 0d |  | 5,10 |
| 9 | 1.1.2 | **"Регламент разработки технического задания инвестиционного проекта"** |  | 19d | 2004-10-28 | 2004-11-24 | 3 | 0d |  | 10 |
| 10 | 1.1.2.1 | Разработка |  | 2w | 2004-10-28 | 2004-11-11 |  | 0d |  | 10 |
| 11 | 1.1.2.2 | Согласование |  | 5d | 2004-11-12 | 2004-11-18 | 10 | 0d |  | 10 |
| 12 | 1.1.2.3 | Подготовка приказа об утверждении |  | 2d | 2004-11-19 | 2004-11-22 | 11 | 0d |  | 10 |
| 13 | 1.1.2.4 | Подписание Приказа |  | 2d | 2004-11-23 | 2004-11-24 | 12 | 0d |  | 10 |
| 14 | 1.1.2.5 | Подписаннный Приказ | milestone | 0d | 2004-11-24 | 2004-11-24 | 13 | 0d |  | 10 |
| 15 | 1.1.3 | **"Регламент ведения учетной карточки инвестиционного проекта"** |  | 8d | 2004-11-25 | 2004-12-06 | 9 | 0d |  | 10 |
| 16 | 1.1.3.1 | Разработка |  | 3d | 2004-11-25 | 2004-11-29 |  | 0d |  | 10 |
| 17 | 1.1.3.2 | Согласование |  | 2d | 2004-11-30 | 2004-12-01 | 16 | 0d |  | 10 |
| 18 | 1.1.3.3 | Подготовка приказа об утверждении |  | 2d | 2004-12-02 | 2004-12-03 | 17 | 0d |  | 10 |
| 19 | 1.1.3.4 | Подписание Приказа |  | 1d | 2004-12-06 | 2004-12-06 | 18 | 0d |  | 10 |
| 20 | 1.1.3.5 | Подписаннный Приказ | milestone | 0d | 2004-12-06 | 2004-12-06 | 19 | 0d |  | 10 |
| 21 | 1.1.4 | **"Регламент разработки бизнесплана инвестиционного проекта"** |  | 12d | 2004-12-07 | 2004-12-22 | 15 | 0d |  | 5,10 |
| 22 | 1.1.4.1 | Разработка |  | 1w | 2004-12-07 | 2004-12-13 |  | 0d |  | 5,10 |
| 23 | 1.1.4.2 | Согласование |  | 3d | 2004-12-14 | 2004-12-16 | 22 | 0d |  | 5,10 |
| 24 | 1.1.4.3 | Подготовка приказа об утверждении |  | 2d | 2004-12-17 | 2004-12-20 | 23 | 0d |  | 5,10 |
| 25 | 1.1.4.4 | Подписание Приказа |  | 2d | 2004-12-21 | 2004-12-22 | 24 | 0d |  | 5,10 |
| 26 | 1.1.4.5 | Подписаннный Приказ | milestone | 0d | 2004-12-22 | 2004-12-22 | 25 | 0d |  | 5,10 |

| ID | WBS | Task | Type | Duration | Start | Finish | Predecessors | Total slack | Free slack | Constraint | Text1 |
| --- | --- | --- | --- | --- | --- | --- | --- | --- | --- | --- | --- |
| 27 | 1.1.5 | **"Положение о проведения тендеров"** |  | 42d | 2004-09-13 | 2004-11-10 |  | 40d |  |  | 5,10 |
| 28 | 1.1.5.1 | Предложения о внесении изменений в "Положение" |  | 2d | 2004-09-13 | 2004-09-14 |  | 43d | 0d | start no earlier than 2004-09-13 | 5,10 |
| 29 | 1.1.5.2 | Контроль внесения изменений |  | 2mo | 2004-09-15 | 2004-11-10 | 28 | 43d |  |  | 5,10 |
| 30 | 1.1.6 | **"Регламент проведения аккредитации поставщиков товаров и услуг для инвестиционных проектов"** |  | 5d | 2004-12-22 | 2004-12-29 | 21 | 0d |  |  | 5,10 |
| 31 | 1.1.6.1 | Разработка |  | 5d | 2004-12-23 | 2004-12-29 |  | 0d |  |  | 5,10 |
| 32 | 1.1.6.2 | Согласование |  | 2d | 2004-12-23 | 2004-12-24 |  | 3d |  |  | 5,10 |
| 33 | 1.1.6.3 | Подготовка приказа об утверждении |  | 2d | 2004-12-23 | 2004-12-24 |  | 3d |  |  | 5,10 |
| 34 | 1.1.6.4 | Подписание Приказа |  | 1d | 2004-12-23 | 2004-12-23 |  | 4d |  |  | 5,10 |
| 35 | 1.1.6.5 | Подписаннный Приказ | milestone | 0d | 2004-12-22 | 2004-12-22 |  | 5d |  |  | 5,10 |
| 36 | 1.1.7 | **"Регламент подготовки и исполнения договоров"** |  | 5d | 2004-12-29 | 2005-01-06 | 30 | 0d |  |  | 5,10 |
| 37 | 1.1.7.1 | Разработка |  | 4d | 2004-12-30 | 2005-01-05 |  | 1d |  |  | 5,10 |
| 38 | 1.1.7.2 | Согласование |  | 5d | 2004-12-30 | 2005-01-06 |  | 0d |  |  | 5,10 |
| 39 | 1.1.7.3 | Подготовка приказа об утверждении |  | 2d | 2004-12-30 | 2005-01-03 |  | 3d |  |  | 5,10 |
| 40 | 1.1.7.4 | Подписание Приказа |  | 1d | 2004-12-30 | 2004-12-30 |  | 4d |  |  | 5,10 |
| 41 | 1.1.7.5 | Подписаннный Приказ | milestone | 0d | 2004-12-29 | 2004-12-29 |  | 5d | 0d |  | 5,10 |
| 42 | 1.2 | **Типовые договоры** |  | 13d | 2004-10-11 | 2004-10-27 |  | 49d |  |  | 10 |
| 43 | 1.2.1 | Типовой договор строительства "под ключ" |  | 1w | 2004-10-11 | 2004-10-15 |  | 57d |  | start no earlier than 2004-10-11 | 10 |
| 44 | 1.2.2 | Типовой договор поставки оборудования |  | 1w | 2004-10-11 | 2004-10-15 |  | 57d |  | start no earlier than 2004-10-11 | 10 |
| 45 | 1.2.3 | Типовой договор выполнения строительных работ |  | 1w | 2004-10-11 | 2004-10-15 |  | 57d |  | start no earlier than 2004-10-11 | 10 |
| 46 | 1.2.4 | Типовой договор выполнения монтажных работ" |  | 1w | 2004-10-11 | 2004-10-15 |  | 57d |  | start no earlier than 2004-10-11 | 10 |
| 47 | 1.2.5 | Типовой договор выполнения пуско-наладочных работ |  | 1w | 2004-10-11 | 2004-10-15 |  | 57d |  | start no earlier than 2004-10-11 | 10 |
| 48 | 1.2.6 | Типовой договор выполнения услуг |  | 1w | 2004-10-11 | 2004-10-15 |  | 49d | 0d | start no earlier than 2004-10-11 | 10 |
| 49 | 1.2.7 | Проверка типовых договоров |  | 1w | 2004-10-18 | 2004-10-22 | 48 | 49d | 0d |  | 10 |
| 50 | 1.2.8 | Подготовка приказа о введении договоров |  | 3d | 2004-10-25 | 2004-10-27 | 49 | 49d | 0d |  | 10 |
| 51 | 1.2.9 | Подписанный приказ | milestone | 0d | 2004-10-27 | 2004-10-27 | 50 | 49d |  | start no earlier than 2004-10-18 | 10 |

| ID | WBS | Task | Type | Duration | Start | Finish | Predecessors | Total slack | Free slack | Constraint | Text1 |
| --- | --- | --- | --- | --- | --- | --- | --- | --- | --- | --- | --- |
| 52 | 1.3 | **Система планирования и отчетности** |  | 49d? | 2004-09-20 | 2004-11-26 |  | 28d |  |  | 5,10 |
| 53 | 1.3.1 | **"Регламент разработки, согласования и защиты финансовых планов инвестиционных проектов"** |  | 21d | 2004-10-07 | 2004-11-04 |  | 43d |  |  | 5,10 |
| 54 | 1.3.1.1 | Разработка |  | 10d | 2004-10-07 | 2004-10-20 |  | 43d | 0d | start no earlier than 2004-10-07 | 5,10 |
| 55 | 1.3.1.2 | Проверка регламента |  | 5d | 2004-10-21 | 2004-10-27 | 54 | 43d | 0d |  | 5,10 |
| 56 | 1.3.1.3 | Согласование |  | 3d | 2004-10-28 | 2004-11-01 | 55 | 43d | 0d |  | 5,10 |
| 57 | 1.3.1.4 | Подготовка приказа об утверждении |  | 2d | 2004-11-02 | 2004-11-03 | 56 | 43d | 0d |  | 5,10 |
| 58 | 1.3.1.5 | Подписание Приказа |  | 1d | 2004-11-04 | 2004-11-04 | 57 | 43d | 0d |  | 5,10 |
| 59 | 1.3.1.6 | Подписанный Приказ | milestone | 0d | 2004-11-04 | 2004-11-04 | 58 | 43d |  |  | 5,10 |
| 60 | 1.3.2 | **Разработка долгосрочных планов инвестиционных проектов** |  | 35d | 2004-10-08 | 2004-11-26 |  | 28d |  |  |  |
| 61 | 1.3.2.1 | Разработка рабочих планов инвестиционных проектов на IV квартал 2004 г. |  | 1w | 2004-10-08 | 2004-10-14 |  | 28d | 0d | start no earlier than 2004-10-08 |  |
| 62 | 1.3.2.2 | Разработка финансовых планов инвестиционных проектов на IV квартал 2004 г. |  | 1w | 2004-10-15 | 2004-10-21 | 61 | 28d | 0d |  |  |
| 63 | 1.3.2.3 | Готовые планы IV квартала 2004 г. | milestone | 0d | 2004-10-21 | 2004-10-21 | 62 | 28d | 0d |  |  |
| 64 | 1.3.2.4 | Разработка рабочих планов инвестиционных проектов на 2005 год |  | 1w | 2004-10-22 | 2004-10-28 | 63 | 28d | 0d |  |  |
| 65 | 1.3.2.5 | Согласование рабочих планов инвестиционных проектов на 2005 г. |  | 1w | 2004-10-29 | 2004-11-04 | 64 | 28d | 0d |  |  |
| 66 | 1.3.2.6 | Разработка финпланов инвестиционных проектов |  | 1w | 2004-11-05 | 2004-11-12 | 65 | 28d | 0d |  |  |
| 67 | 1.3.2.7 | Согласование финпланов |  | 1w | 2004-11-15 | 2004-11-19 | 66 | 28d | 0d |  |  |
| 68 | 1.3.2.8 | Защита рабочих планов и финпланов на Инвестиционном комитете |  | 3d | 2004-11-22 | 2004-11-24 | 67 | 28d | 0d |  |  |
| 69 | 1.3.2.9 | Корпоративная процедура утверждения планов Правлением |  | 2d | 2004-11-25 | 2004-11-26 | 68 | 28d | 0d |  |  |
| 70 | 1.3.2.10 | Утвержденные рабочие и финансовые планы | milestone | 0d | 2004-11-26 | 2004-11-26 | 69 | 28d |  |  |  |
| 71 | 1.3.3 | **"Регламент проведения селекторных совещаний"** |  | 29d? | 2004-09-20 | 2004-10-28 |  | 48d |  |  | 5,10 |
| 72 | 1.3.3.1 | Разработка |  | 1mo | 2004-09-20 | 2004-10-15 |  | 48d | 0d | start no earlier than 2004-09-20 | 5,10 |
| 73 | 1.3.3.2 | Проверка регламента |  | 3d | 2004-10-18 | 2004-10-20 | 72 | 48d | 0d |  | 5,10 |
| 74 | 1.3.3.3 | Согласование |  | 3d | 2004-10-21 | 2004-10-25 | 73 | 48d | 0d |  | 5,10 |
| 75 | 1.3.3.4 | Подготовка приказа об утвержденииаспоряжения |  | 2d | 2004-10-26 | 2004-10-27 | 74 | 48d | 0d |  | 5,10 |
| 76 | 1.3.3.5 | Подписание распоряжения |  | 1d? | 2004-10-28 | 2004-10-28 | 75 | 48d | 0d |  | 5,10 |
| 77 | 1.3.3.6 | Подписанное распоряжение | milestone | 0d | 2004-10-28 | 2004-10-28 | 76 | 48d |  |  | 5,10 |

| ID | WBS | Task | Type | Duration | Start | Finish | Predecessors | Total slack | Free slack | Constraint | Text1 |
| --- | --- | --- | --- | --- | --- | --- | --- | --- | --- | --- | --- |
| 78 | 1.3.4 | **"Регламент составления периодических отчетов менеджеров проетов"** |  | 29d | 2004-09-20 | 2004-10-28 |  | 48d |  |  | 5,10 |
| 79 | 1.3.4.1 | Разработка |  | 1mo | 2004-09-20 | 2004-10-15 |  | 48d | 0d | start no earlier than 2004-09-20 | 5,10 |
| 80 | 1.3.4.2 | Проверка регламента |  | 3d | 2004-10-18 | 2004-10-20 | 79 | 48d | 0d |  | 5,10 |
| 81 | 1.3.4.3 | Согласование |  | 3d | 2004-10-21 | 2004-10-25 | 80 | 48d | 0d |  | 5,10 |
| 82 | 1.3.4.4 | Подготовка приказа об утверждении |  | 2d | 2004-10-26 | 2004-10-27 | 81 | 48d | 0d |  | 5,10 |
| 83 | 1.3.4.5 | Подписание Приказа |  | 1d | 2004-10-28 | 2004-10-28 | 82 | 48d | 0d |  | 5,10 |
| 84 | 1.3.4.6 | Подписаннный Приказ | milestone | 0d | 2004-10-28 | 2004-10-28 | 83 | 48d |  |  | 5,10 |
| 85 | 2 | **Работа с персоналом** |  | 86d? | 2004-09-01 | 2004-12-30 |  | 4d |  |  |  |
| 86 | 2.1 | **Создание кадрового резерва PM** |  | 20d? | 2004-10-18 | 2004-11-15 |  | 30d |  |  |  |
| 87 | 2.1.1 | Проведение совещания с молодыми технологами |  | 1w | 2004-10-18 | 2004-10-22 |  | 30d | 0d | start no earlier than 2004-10-18 |  |
| 88 | 2.1.2 | Отбор заявок на кандидаты в резерв PM |  | 1w | 2004-10-25 | 2004-10-29 | 87 | 30d | 0d |  |  |
| 89 | 2.1.3 | Проведение тестирования кандидатов |  | 1w | 2004-11-01 | 2004-11-05 | 88 | 30d | 0d |  |  |
| 90 | 2.1.4 | Согласование кандидатур в резерв PM |  | 2d | 2004-11-09 | 2004-11-10 | 89 | 30d | 0d |  |  |
| 91 | 2.1.5 | Подготовка приказа об утверждении |  | 2d | 2004-11-11 | 2004-11-12 | 90 | 30d | 0d |  |  |
| 92 | 2.1.6 | Подписание Приказа |  | 1d? | 2004-11-15 | 2004-11-15 | 91 | 30d | 0d |  |  |
| 93 | 2.1.7 | Подписаннный Приказ | milestone | 0d | 2004-11-15 | 2004-11-15 | 92 | 30d | 0d |  |  |
| 94 | 2.2 | **Создание рабочих групп по проектам** |  | 10d? | 2004-10-18 | 2004-10-29 |  | 41d |  |  |  |
| 95 | 2.2.1 | Подготовка предварительных списков рабочих групп |  | 1w | 2004-10-18 | 2004-10-22 |  | 41d | 0d | start no earlier than 2004-10-18 |  |
| 96 | 2.2.2 | Согласование списков |  | 2d | 2004-10-25 | 2004-10-26 | 95 | 41d | 0d |  |  |
| 97 | 2.2.3 | Подготовка приказа об утверждении |  | 2d | 2004-10-27 | 2004-10-28 | 96 | 41d | 0d |  |  |
| 98 | 2.2.4 | Подписание Приказа |  | 1d? | 2004-10-29 | 2004-10-29 | 97 | 41d | 0d |  |  |
| 99 | 2.2.5 | Подписанный Приказ о назначение PM и рабочих групп | milestone | 0d | 2004-10-29 | 2004-10-29 | 98 | 41d | 0d |  |  |
| 100 | 2.3 | **Обучение PM, рабочих групп и резерва** |  | 86d | 2004-09-01 | 2004-12-30 |  | 4d |  |  |  |
| 101 | 2.3.1 | Разработка программ обучения |  | 1mo | 2004-10-04 | 2004-10-29 |  | 47d |  | start no earlier than 2004-10-04 |  |
| 102 | 2.3.2 | Подбор подрядчиков на проведение обучения PM |  | 1w | 2004-10-13 | 2004-10-19 |  | 50d | 0d | start no earlier than 2004-10-13 |  |
| 103 | 2.3.3 | Проведение обучения PM программе MS Project |  | 1w | 2004-10-20 | 2004-10-26 | 102 | 50d |  | start no earlier than 2004-10-20 |  |
| 104 | 2.3.4 | Проведение обучения PM основам экономики и финансов |  | 2d | 2004-09-01 | 2004-09-02 |  | 88d |  |  |  |

| ID | WBS | Task | Type | Duration | Start | Finish | Predecessors | Total slack | Free slack | Constraint |
| --- | --- | --- | --- | --- | --- | --- | --- | --- | --- | --- |
| 105 | 2.3.5 | **Проведение обучения PM корпоративным стандартам** |  | 18d | 2004-12-07 | 2004-12-30 |  | 4d |  |  |
| 106 | 2.3.5.1 | Обучение составлению техзадания и учетной карточки |  | 1d | 2004-12-07 | 2004-12-07 | 20 | 21d |  | start no earlier than 2004-12-07 |
| 107 | 2.3.5.2 | Обучение составлению бизнесплана |  | 1d | 2004-12-23 | 2004-12-23 | 26 | 9d |  |  |
| 108 | 2.3.5.3 | Обучение работе с поставщиками товаров и услуг |  | 1d | 2004-12-30 | 2004-12-30 | 41 | 4d |  |  |
| 109 | 2.3.6 | Подбор подрядчиков на проведение обучения рабочих групп |  | 1w | 2004-11-02 | 2004-11-09 | 110 | 41d |  |  |
| 110 | 2.3.7 | Проведение обучения рабочих групп программе MS Project |  | 1d | 2004-11-01 | 2004-11-01 | 99 | 41d | 0d |  |
| 111 | 2.3.8 | Проведение обучения рабочих групп основам экономики и финансов |  | 1d | 2004-11-02 | 2004-11-02 | 110 | 44d | 0d |  |
| 112 | 2.3.9 | Проведение обучения рабочих групп корпоративным стандартам |  | 1d | 2004-11-03 | 2004-11-03 | 111 | 44d |  |  |
| 113 | 2.3.10 | Подбор подрядчиков на проведение обучения резерва |  | 1w | 2004-11-18 | 2004-11-24 | 114 | 30d |  |  |
| 114 | 2.3.11 | Проведение обучения резерва программе MS Project |  | 2d | 2004-11-16 | 2004-11-17 | 93 | 30d | 0d |  |
| 115 | 2.3.12 | Проведение обучения резерва основам экономики и финансов |  | 1d | 2004-11-18 | 2004-11-18 | 114 | 33d | 0d |  |
| 116 | 2.3.13 | Проведение обучения резерва корпоративным стандартам |  | 1d | 2004-11-19 | 2004-11-19 | 115 | 33d |  |  |
| 117 | 3 | **Система стимулирования PM и рабочих групп** |  | 59d | 2004-10-11 | 2005-01-03 |  | 3d |  |  |
| 118 | 3.1 | **Внедрение новой системы оплаты труда и премирования PM** |  | 59d | 2004-10-11 | 2005-01-03 |  | 3d |  |  |
| 119 | 3.1.1 | Разработка проекта "Положения об оплате труда и премировании" |  | 2w | 2004-10-11 | 2004-10-22 |  | 3d | 0d | start no earlier than 2004-10-11 |
| 120 | 3.1.2 | Переговоры с PM о методах внедрения новой системы оплаты труда |  | 1d | 2004-10-25 | 2004-10-25 | 119 | 3d | 0d |  |
| 121 | 3.1.3 | Согласование проекта "Положения" |  | 1w | 2004-10-26 | 2004-11-01 | 120 | 3d | 0d |  |
| 122 | 3.1.4 | Подготовка Приказа о новой системе оплаты труда PM |  | 2d | 2004-11-02 | 2004-11-03 | 121 | 3d | 0d |  |
| 123 | 3.1.5 | Подписание Приказа |  | 1d | 2004-11-04 | 2004-11-04 | 122 | 3d | 0d |  |
| 124 | 3.1.6 | Срок по ТК РФ для вступления Приказа в силу |  | 2mo | 2004-11-05 | 2005-01-03 | 123 | 3d | 0d |  |
| 125 | 3.1.7 | Начало работы новой системы оплаты труда | milestone | 0d | 2005-01-03 | 2005-01-03 | 124 | 3d |  |  |
| 126 | 3.2 | **Внедрение новой системы премирования рабочих групп** |  | 13d | 2004-10-25 | 2004-11-11 |  | 39d |  |  |
| 127 | 3.2.1 | Разработка "Положения о премировании рабочих групп" |  | 1w | 2004-10-25 | 2004-10-29 | 119 | 39d | 0d |  |
| 128 | 3.2.2 | Согласование проекта "Положения" |  | 1w | 2004-11-01 | 2004-11-05 | 127 | 39d | 0d |  |
| 129 | 3.2.3 | Подготовка Приказа о введении "Положения" |  | 2d | 2004-11-09 | 2004-11-10 | 128 | 39d | 0d |  |
| 130 | 3.2.4 | Подписание Приказа |  | 1d | 2004-11-11 | 2004-11-11 | 129 | 39d | 0d |  |
| 131 | 3.2.5 | Начало работы новой системы премирования | milestone | 0d | 2004-11-11 | 2004-11-11 | 130 | 39d |  |  |

| ID | WBS | Task | Type | Duration | Start | Finish | Predecessors | Total slack | Free slack | Constraint |
| --- | --- | --- | --- | --- | --- | --- | --- | --- | --- | --- |
| 132 | 4 | **Материально-техническое и программное обеспечение** |  | 22d | 2004-09-20 | 2004-10-19 |  | 55d |  |  |
| 133 | 4.1 | Обеспечение PM компьютерами |  | 1mo | 2004-09-20 | 2004-10-15 |  | 57d |  | start no earlier than 2004-09-20 |
| 134 | 4.2 | Обеспечение программой MS Project |  | 2w | 2004-10-06 | 2004-10-19 |  | 55d |  | start no earlier than 2004-10-06 |
| 135 | 4.3 | Обеспечение PM рабочим местом с телефоном |  | 1mo | 2004-09-20 | 2004-10-15 |  | 57d |  | start no earlier than 2004-09-20 |
| 136 | 5 | **Изменение должностного статуса, прав и обязанностей PM** |  | 46d? | 2004-09-01 | 2004-11-03 |  | 44d |  |  |
| 137 | 5.1 | **Внедрение новых должностных инструкций PM** |  | 13d | 2004-10-18 | 2004-11-03 |  | 44d |  |  |
| 138 | 5.1.1 | Разработка "Инструкции" |  | 1w | 2004-10-18 | 2004-10-22 |  | 44d | 0d | start no earlier than 2004-10-18 |
| 139 | 5.1.2 | Согласование инструкции |  | 1w | 2004-10-25 | 2004-10-29 | 138 | 44d | 0d |  |
| 140 | 5.1.3 | Подготовка Приказа |  | 2d | 2004-11-01 | 2004-11-02 | 139 | 44d | 0d |  |
| 141 | 5.1.4 | Подписание Приказа |  | 1d | 2004-11-03 | 2004-11-03 | 140 | 44d | 0d |  |
| 142 | 5.1.5 | Подписанный Приказ | milestone | 0d | 2004-11-03 | 2004-11-03 | 141 | 44d |  |  |
| 143 | 5.2 | **Внедрение новой структуры подчиненности группы PM** |  | 2d? | 2004-09-01 | 2004-09-02 |  | 88d |  |  |
| 144 | 5.2.1 | Подготовка Приказа |  | 1d? | 2004-09-01 | 2004-09-01 |  | 88d | 0d |  |
| 145 | 5.2.2 | Подписание Приказа |  | 1d? | 2004-09-02 | 2004-09-02 | 144 | 88d | 0d |  |
| 146 | 5.2.3 | Подписанный Приказ | milestone | 0d | 2004-09-02 | 2004-09-02 | 145 | 88d |  |  |
| 147 | 6 | **Внедрение корпоративных процедур в ООО "ХГ НИТОЛ"** |  | 47d? | 2004-09-01 | 2004-11-04 |  | 43d |  |  |
| 148 | 6.1 | **Внедрение "Положения о Департаменте развития"** |  | 4d? | 2004-09-01 | 2004-09-06 |  | 86d |  |  |
| 149 | 6.1.1 | Разработка |  | 1d? | 2004-09-01 | 2004-09-01 |  | 89d |  |  |
| 150 | 6.1.2 | Согласование |  | 1d? | 2004-09-02 | 2004-09-02 | 149 | 86d | 0d |  |
| 151 | 6.1.3 | Подготовка приказа об утверждении |  | 1d? | 2004-09-03 | 2004-09-03 | 150 | 86d | 0d |  |
| 152 | 6.1.4 | Подписание Приказа |  | 1d? | 2004-09-06 | 2004-09-06 | 151 | 86d | 0d |  |
| 153 | 6.1.5 | Подписаннный Приказ | milestone | 0d | 2004-09-06 | 2004-09-06 | 152 | 86d |  |  |
| 154 | 6.2 | **Внедрение "Положения об инвестиционном комитете ХГ НИТОЛ""** |  | 28d | 2004-09-28 | 2004-11-04 |  | 43d |  |  |
| 155 | 6.2.1 | Разработка |  | 1mo | 2004-09-28 | 2004-10-25 |  | 43d | 0d | start no earlier than 2004-09-28 |
| 156 | 6.2.2 | Согласование |  | 1w | 2004-10-26 | 2004-11-01 | 155 | 43d | 0d |  |
| 157 | 6.2.3 | Подготовка приказа об утверждении |  | 2d | 2004-11-02 | 2004-11-03 | 156 | 43d | 0d |  |
| 158 | 6.2.4 | Подписание Приказа |  | 1d | 2004-11-04 | 2004-11-04 | 157 | 43d | 0d |  |
| 159 | 6.2.5 | Подписаннный Приказ | milestone | 0d | 2004-11-04 | 2004-11-04 | 158 | 43d |  |  |
